# OB-03 - fund.sloof+metselwerk

Schedule from MS Project, 2003-01-12 to 2003-02-05, status date 2003-01-08.
BAM Nelissen Van Egteren

## Calendars

- ALLEEN WERKDAGEN: Mon-Fri 08:30-12:30, 13:00-17:00; Sat-Sun off. Exceptions (off unless hours are given): 2003-01-11 to 2003-01-12 08:30-12:30, 13:00-17:00, 2003-01-18 to 2003-01-19 08:30-12:30, 13:00-17:00, 2003-01-25 to 2003-01-26 08:30-12:30, 13:00-17:00, 2003-02-01 to 2003-02-02 08:30-12:30, 13:00-17:00.

## Schedule

| ID | WBS | Task | Type | Duration | Start | Finish | Predecessors | Total slack |
| --- | --- | --- | --- | --- | --- | --- | --- | --- |
| 1 | 1 | **ONDERBOUWFASE** |  | 25d | 2003-01-12 | 2003-02-05 |  | 0d |
| 2 | 1.1 | werkvloer randkist+beton |  | 2d | 2003-01-12 | 2003-01-13 |  | 0d |
| 3 | 1.2 | wapening sloof vlechten |  | 2d | 2003-01-14 | 2003-01-15 | 2SS+2d | 0d |
| 4 | 1.3 | sloofbekisting stellen |  | 2d | 2003-01-16 | 2003-01-17 | 3SS+2d | 0d |
| 5 | 1.4 | fund.sloven beton storten |  | 2d | 2003-01-18 | 2003-01-19 | 4SS+2d | 0d |
| 6 | 1.5 | fundering ontkisten |  | 2d | 2003-01-19 | 2003-01-20 | 5SS+1d | 0d |
| 7 | 1.6 | metselprofielen stellen |  | 2d | 2003-01-21 | 2003-01-22 | 6SS+2d | 0d |
| 8 | 1.7 | fundering metselen |  | 4d | 2003-01-23 | 2003-01-26 | 7SS+2d | 0d |
| 9 | 1.8 | leidingen onder vloer monteren |  | 4d | 2003-01-27 | 2003-01-30 | 8SS+4d | 0d |
| 10 | 1.9 | systeemvloer leggen |  | 3d | 2003-01-30 | 2003-02-01 | 9SS+3d | 0d |
| 11 | 1.10 | randkist+sparingkist vloer |  | 3d | 2003-02-01 | 2003-02-03 | 10SS+2d | 0d |
| 12 | 1.11 | systeemvloer afstorten |  | 1d | 2003-02-04 | 2003-02-04 | 11SS+3d | 0d |
| 13 | 1.12 | maatvoeren voor bovenbouw |  | 1d | 2003-02-05 | 2003-02-05 | 12SS+1d | 0d |
| 14 | 1.13 | start bovenbouw | milestone | 0d | 2003-02-05 | 2003-02-05 | 13SS+1d | 0d |
